# SUB PROYECTO A3 - CRONOGRAMA OFERTA

Schedule from Primavera P6, 2023-04-25 to 2023-12-02, data date 2023-04-25.

## Calendars

- Calendario Lacramarca 7D-1T: Mon-Sun 07:00-12:00, 13:00-18:00.
- DiasCalendario: Mon-Sun 08:00-16:00.

## Resources

| Resource | Group |
| --- | --- |
| HH | labor |
| HM | equipment |
| EXCAVACIONES | material |
| RELLENOS | material |
| ENROCADOS | material |

## Schedule

| ID | WBS | Activity | Type | Duration | Start | Finish | Predecessors | Total float | Free float |
| --- | --- | --- | --- | --- | --- | --- | --- | --- | --- |
|  | 000 | **GENERALES** |  |  | 2023-04-25 | 2023-12-02 |  |  |  |
|  | M | **GESTION** |  |  | 2023-04-25 | 2023-05-02 |  |  |  |
|  | 10 | **CONTROL DE PROYECTOS** |  |  | 2023-04-25 | 2023-05-02 |  |  |  |
|  | 01 | **HITOS DE CONTROL** |  |  | 2023-04-25 | 2023-05-02 |  |  |  |
|  | 01 | **HITOS CLAVE** |  |  | 2023-04-25 | 2023-05-02 |  |  |  |
| M.10.01.01.11 |  | Carta de Adjudicación | milestone | 0d | 2023-04-25 | 2023-04-25 |  | 0d |  |
| M.10.01.01.12 |  | KOM | milestone | 0d | 2023-05-02 | 2023-05-02 | M.10.01.01.11 SS+7d | 0d |  |
|  | C | **CONSTRUCCION** |  |  | 2023-04-25 | 2023-12-02 |  |  |  |
|  | 90 | **TRABAJOS PRELIMINARES** |  |  | 2023-04-25 | 2023-12-02 |  |  |  |
|  | 02 | **COSTOS DEL CONTRATISTA GENERAL** |  |  | 2023-05-02 | 2023-05-17 |  |  |  |
|  | 01 | **MOVILIZACIÓN** |  |  | 2023-05-02 | 2023-05-17 |  |  |  |
| C.90.02.01.11 |  | Movilización de equipos - Movimiento de Tierras |  | 16d | 2023-05-02 | 2023-05-17 | M.10.01.01.12 SS | 0d |  |
|  | 03 | **GASTOS GENERALES** |  |  | 2023-04-25 | 2023-12-02 |  |  |  |
| C.90.03.11 |  | Gastos Generales | level of effort | 222d | 2023-04-25 | 2023-12-02 | M.10.01.01.11 SS | 0d |  |
|  | 501 | **DEFENSAS RIBEREÑAS** |  |  | 2023-05-18 | 2023-12-02 |  |  |  |
|  | M | **GESTION** |  |  | 2023-05-18 | 2023-12-02 |  |  |  |
|  | 10 | **CONTROL DE PROYECTOS** |  |  | 2023-05-18 | 2023-12-02 |  |  |  |
|  | 01 | **HITOS DE CONTROL** |  |  | 2023-05-18 | 2023-12-02 |  |  |  |
|  | 01 | **HITOS CLAVE** |  |  | 2023-05-18 | 2023-12-02 |  |  |  |
| M.10.01.01.13 |  | Fecha Clave 1: Acceso al Sitio | milestone | 0d | 2023-05-18 | 2023-05-18 | M.10.01.01.12 SS+16d | 0d |  |
| M.10.01.01.14 |  | Fecha clave 2: Inicio de excavación | milestone | 0d | 2023-05-23 | 2023-05-23 | M.10.01.01.13 SS+5d | 172d | 0d |
| M.10.01.01.15 |  | Fecha Clave 3: Inicio de rellenos | milestone | 0d | 2023-06-14 | 2023-06-14 | M.10.01.01.14 SS+22d | 172d |  |
| M.10.01.01.16 |  | Fecha Clave 4: Culminación | milestone | 0d | 2023-12-02 | 2023-12-02 | M.10.01.01.13 SF+199d | 0d |  |
|  | 02 | **HITOS PLANIFICADOS** |  |  | 2023-05-18 | 2023-12-02 |  |  |  |
| M.10.01.02.11 |  | Hito Planificado 1: Acceso al sitio | milestone | 0d | 2023-05-18 | 2023-05-18 | C.90.02.01.11 | 0d |  |
| M.10.01.02.12 |  | Hito Planificado 2: Inicio de excavación | milestone | 0d | 2023-05-23 | 2023-05-23 | C.70.10.02.2.11 SS | 194d |  |
| M.10.01.02.13 |  | Hito Planificado 3: Inicio de rellenos | milestone | 0d | 2023-06-14 | 2023-06-14 | C.70.10.01.14 SS | 172d |  |
| M.10.01.02.14 |  | Hito Planificado 4: Culminación | milestone | 0d | 2023-12-02 | 2023-12-02 | C.90.03.11 FF, C.90.02.08.11 FF, C.90.02.06.11 FF, C.90.02.05.11 FF, T.20.12 FF, C.90.02.02.11 FF, C.90.02.03.11 FF | 0d |  |

| ID | WBS | Activity | Type | Duration | Start | Finish | Predecessors | Total float | Free float | Constraint | Calendar | Resources |
| --- | --- | --- | --- | --- | --- | --- | --- | --- | --- | --- | --- | --- |
|  | C | **CONSTRUCCIÓN** |  |  | 2023-05-18 | 2023-12-02 |  |  |  |  |  |  |
|  | 90 | **TRABAJOS PRELIMINARES** |  |  | 2023-05-18 | 2023-12-02 |  |  |  |  |  |  |
|  | 02 | **COSTOS DEL CONTRATISTA GENERAL** |  |  | 2023-05-18 | 2023-12-02 |  |  |  |  |  |  |
|  | 01 | **MOVILIZACIÓN** |  |  | 2023-09-22 | 2023-10-05 |  |  |  |  |  |  |
| C.90.02.01.12 |  | Movilización de equipos - Paisajismo |  | 14d | 2023-09-22 | 2023-10-05 | C.70.10.04.15 | 26d | 0d |  |  |  |
|  | 02 | **TRAZO Y REPLANTEO** |  |  | 2023-05-18 | 2023-12-02 |  |  |  |  |  |  |
| C.90.02.02.11 |  | Topografia y georreferenciación | level of effort | 199d | 2023-05-18 | 2023-12-02 | M.10.01.01.13 SS | 0d |  |  |  | HH [18108.1 h] |
| C.90.02.02.12 |  | Trazo y replanteo preliminar - Paisajismo | level of effort | 29d | 2023-10-06 | 2023-11-03 | C.70.03.01.11 SS | 26d | 0d |  |  | HH [78.67 h] |
|  | 03 | **SEGURIDAD INDUSTRIAL Y SALUD OCUPACIONAL** |  |  | 2023-05-18 | 2023-12-02 |  |  |  |  |  |  |
| C.90.02.03.11 |  | Seguridad y salud ocupacional | level of effort | 199d | 2023-05-18 | 2023-12-02 | M.10.01.01.13 SS | 0d |  |  |  |  |
|  | 04 | **INSTALACIONES PROVISIONALES PARA OBRA** |  |  | 2023-05-18 | 2023-11-25 |  |  |  |  |  |  |
| C.90.02.04.11 |  | Instalación de facilidades de obra |  | 15d | 2023-05-18 | 2023-06-01 | C.90.02.01.11 | 182d | 0d |  |  |  |
| C.90.02.04.12 |  | Colocación de Cartel de Identificación |  | 2d | 2023-06-02 | 2023-06-03 | C.90.02.04.11 | 182d |  |  |  | HH [31.55 h]; HM [0.38 h] |
| C.90.02.04.13 |  | Gastos de facilidades de obra | level of effort | 175d | 2023-06-04 | 2023-11-25 | C.90.02.04.12 | 0d |  |  |  |  |
|  | 05 | **GESTIÓN DE RESIDUOS** |  |  | 2023-05-18 | 2023-12-02 |  |  |  |  |  |  |
| C.90.02.05.12 |  | Acondicionamiento de DME | level of effort | 175d | 2023-05-18 | 2023-11-08 | M.10.01.02.11 SS | 0d |  |  |  | HH [11281.2 h]; HM [7658.81 h] |
| C.90.02.05.11 |  | Restauración de áreas de instalaciones provisionales |  | 24d | 2023-11-09 | 2023-12-02 | C.90.02.05.12 | 0d |  | as late as possible |  | HH [144 h]; HM [41.6 h] |
|  | 06 | **PLAN DE VIGILANCIA, PREVENCIÓN Y CONTROL COVID 19** |  |  | 2023-05-18 | 2023-12-02 |  |  |  |  |  |  |
| C.90.02.06.11 |  | Implementación del Plan para la vigilancia, prevención y control de COVID -19 | level of effort | 199d | 2023-05-18 | 2023-12-02 | M.10.01.02.11 SS, M.10.01.01.14 SS | 0d |  |  |  |  |
|  | 07 | **TRANSPORTE** |  |  | 2023-05-23 | 2023-10-19 |  |  |  |  |  |  |
| C.90.02.07.15 |  | Transporte de material excedente < 1km | level of effort | 81d | 2023-05-23 | 2023-08-11 | M.10.01.02.12 SS | 59d | 0d |  | DiasCalendario | HH [10211.6 h]; HM [7294 h] |
| C.90.02.07.16 |  | Transporte de material excedente >1km | level of effort | 81d | 2023-05-23 | 2023-08-11 | M.10.01.02.12 SS | 59d | 0d |  | DiasCalendario | HH [82761.8 h]; HM [59115.6 h] |
| C.90.02.07.13 |  | Transporte de roca <1km | level of effort | 114d | 2023-06-22 | 2023-10-13 | C.70.10.01.17 SS | 37d | 0d |  | DiasCalendario | HH [3375.69 h]; HM [2411.21 h] |
| C.90.02.07.14 |  | Transporte de roca >1km | level of effort | 71d | 2023-06-22 | 2023-08-31 | C.70.10.01.17 SS | 37d | 0d |  | DiasCalendario | HH [52038.6 h]; HM [37170.4 h] |
| C.90.02.07.11 |  | Transporte de material granular < 1km | level of effort | 114d | 2023-06-28 | 2023-10-19 | C.70.11.01.13 SS | 37d | 0d |  | DiasCalendario | HH [799.16 h]; HM [570.83 h] |
| C.90.02.07.12 |  | Transporte de material granular >1km | level of effort | 114d | 2023-06-28 | 2023-10-19 | C.70.11.01.13 SS | 37d | 0d |  | DiasCalendario | HH [387.33 h]; HM [276.66 h] |

| ID | WBS | Activity | Type | Duration | Start | Finish | Predecessors | Total float | Free float | Resources | SECTOR |
| --- | --- | --- | --- | --- | --- | --- | --- | --- | --- | --- | --- |
|  | 08 | **MANTENIMIENTO DE TRANSITO Y SEGURIDAD VIAL** |  |  | 2023-05-18 | 2023-12-02 |  |  |  |  |  |
| C.90.02.08.11 |  | Mantenimiento de tránsito y seguridad vial | level of effort | 199d | 2023-05-18 | 2023-12-02 | M.10.01.02.11 SS | 0d |  | HH [18912.9 h]; HM [5834.84 h] |  |
|  | 80 | **FACILIDADES DE OBRA** |  |  | 2023-05-22 | 2023-06-22 |  |  |  |  |  |
|  | 02 | **DEMOLICIONES** |  |  | 2023-05-24 | 2023-06-22 |  |  |  |  |  |
| C.80.02.16 |  | Demolición de sifon invertido |  | 1d | 2023-05-24 | 2023-05-24 | C.70.01.01.12 SS, C.70.01.01.16 SS | 156d | 41d | HH [11.38 h]; HM [10.14 h] |  |
| C.80.02.11 |  | Demolición de estructuras existentes - Punto de agua 1 |  | 1d | 2023-06-01 | 2023-06-01 | C.70.02.01.01.12 | 167d | 0d | HH [3.81 h]; HM [3.4 h] |  |
| C.80.02.12 |  | Demolición de estructuras existentes - Punto de agua 2 |  | 1d | 2023-06-02 | 2023-06-02 | C.80.02.11 | 167d | 0d | HH [3.81 h]; HM [3.4 h] |  |
| C.80.02.13 |  | Demolición de estructuras existentes - Punto de agua 3 |  | 2d | 2023-06-03 | 2023-06-04 | C.80.02.12 | 167d | 0d | HH [19.07 h]; HM [16.99 h] |  |
| C.80.02.14 |  | Demolición de canal 1 |  | 8d | 2023-06-08 | 2023-06-15 | C.70.01.01.17, C.70.01.01.15 | 29d |  | HH [1452.92 h]; HM [1294.3 h] |  |
| C.80.02.15 |  | Demolición de canal 3 |  | 5d | 2023-06-18 | 2023-06-22 | C.70.01.01.12, C.70.01.01.16 | 132d | 30d | HH [849.44 h]; HM [756.71 h] |  |
|  | 04 | **OBRAS DE DESVIO TEMPORAL** |  |  | 2023-05-22 | 2023-06-19 |  |  |  |  |  |
| C.80.02.19 |  | Conformación de desvió en cauce de río Dique A3-D-02 - Sector 2 |  | 3d | 2023-05-22 | 2023-05-24 | C.70.01.01.14 SS | 69d | 0d | HH [138.1 h]; HM [65.93 h] | S2 |
| C.80.02.17 |  | Conformación de desvió en cauce de río Dique A3-D-01 |  | 2d | 2023-05-25 | 2023-05-26 | C.70.01.01.12 SS+1d | 105d | 0d | HH [72.46 h]; HM [34.59 h] | S4 |
| C.80.02.18 |  | Conformación de desvió en cauce de río Dique A3-D-02 - Sector 1 |  | 2d | 2023-06-01 | 2023-06-02 | C.70.01.01.13 | 77d | 0d | HH [69.91 h]; HM [33.37 h] | S3 |
| C.80.02.23 |  | Conformación de desvió en cauce de río Dique A3-I-03 - Sector 1 |  | 3d | 2023-06-04 | 2023-06-06 | C.70.01.01.18 | 48d | 0d | HH [138.1 h]; HM [65.93 h] | S2 |
| C.80.02.24 |  | Conformación de desvió en cauce de río Dique A3-I-03 - Sector 2 |  | 4d | 2023-06-05 | 2023-06-08 | C.70.01.01.19 | 38d | 0d | HH [162.57 h]; HM [77.61 h] | S1 |
| C.80.02.20 |  | Conformación de desvió en cauce de río Dique A3-D-02 - Sector 3 |  | 4d | 2023-06-08 | 2023-06-11 | C.70.01.01.15 | 2d | 0d | HH [162.57 h]; HM [77.61 h] | S1 |
| C.80.02.22 |  | Conformación de desvió en cauce de río Dique A3-I-02 |  | 2d | 2023-06-08 | 2023-06-09 | C.70.01.01.17 | 0d |  | HH [69.91 h]; HM [33.37 h] | S3 |
| C.80.02.21 |  | Conformación de desvió en cauce de río Dique A3-I-01 |  | 2d | 2023-06-18 | 2023-06-19 | C.70.01.01.16 | 58d | 0d | HH [72.46 h]; HM [34.59 h] | S4 |
|  | 70 | **OBRAS EXTERIORES** |  |  | 2023-05-18 | 2023-11-03 |  |  |  |  |  |
|  | 01 | **PREPARACION DEL SITIO** |  |  | 2023-05-18 | 2023-07-04 |  |  |  |  |  |
|  | 01 | **LIMPIEZA** |  |  | 2023-05-18 | 2023-06-17 |  |  |  |  |  |
| C.70.01.01.11 |  | Roce y limpieza de vías |  | 5d | 2023-05-18 | 2023-05-22 | M.10.01.01.13 SS | 168d | 1d | HH [419.1 h]; HM [190.52 h] |  |
| C.70.01.01.14 |  | Desbroce y limpieza Dique A3-D-02 - Sector 2 |  | 15d | 2023-05-22 | 2023-06-05 | C.70.02.01.01.11 | 69d | 0d | HH [4426.92 h]; HM [1351.21 h] | S2 |
| C.70.01.01.15 |  | Desbroce y limpieza Dique A3-D-02 - Sector 3 |  | 17d | 2023-05-22 | 2023-06-07 | C.70.02.01.01.11 | 2d | 0d | HH [4825.88 h]; HM [1472.98 h] | S1 |
| C.70.01.01.18 |  | Desbroce y limpieza Dique A3-I-03 - Sector 1 |  | 13d | 2023-05-22 | 2023-06-03 | C.70.02.01.01.11 | 48d | 0d | HH [3705.63 h]; HM [1131.05 h] | S2 |
| C.70.01.01.19 |  | Desbroce y limpieza Dique A3-I-03 - Sector 2 |  | 14d | 2023-05-22 | 2023-06-04 | C.70.02.01.01.11 | 38d | 0d | HH [4157.53 h]; HM [1268.98 h] | S1 |
| C.70.01.01.12 |  | Desbroce y limpieza Dique A3-D-01 |  | 7d | 2023-05-24 | 2023-05-30 | C.70.02.01.01.14 | 105d | 0d | HH [2106.26 h]; HM [642.88 h] | S4 |
| C.70.01.01.13 |  | Desbroce y limpieza Dique A3-D-02 - Sector 1 |  | 8d | 2023-05-24 | 2023-05-31 | C.70.02.01.01.14 | 77d | 0d | HH [2267.45 h]; HM [692.08 h] | S3 |
| C.70.01.01.16 |  | Desbroce y limpieza Dique A3-I-01 |  | 25d | 2023-05-24 | 2023-06-17 | C.70.02.01.01.14 | 58d | 0d | HH [7343.51 h]; HM [2241.42 h] | S4 |
| C.70.01.01.17 |  | Desbroce y limpieza Dique A3-I-02 |  | 15d | 2023-05-24 | 2023-06-07 | C.70.02.01.01.14 | 0d |  | HH [4400.09 h]; HM [1343.02 h] | S3 |

| ID | WBS | Activity | Duration | Start | Finish | Predecessors | Total float | Free float | Resources | SECTOR |
| --- | --- | --- | --- | --- | --- | --- | --- | --- | --- | --- |
|  | 02 | **DESCOLMATACIÓN** |  | 2023-05-22 | 2023-07-04 |  |  |  |  |  |
| C.70.01.02.13 |  | Descolmatación Dique A3-D-02 - Sector 2 | 8d | 2023-05-22 | 2023-05-29 | C.80.02.19 SS | 69d | 0d | HH [532.41 h]; HM [343.59 h] | S2 |
| C.70.01.02.21 |  | Relleno no estructural Dique A3-D-02 - Sector 2 | 3d | 2023-05-22 | 2023-05-24 | C.70.01.02.13 SS | 69d | 0d | HH [138.1 h]; HM [65.93 h] | S2 |
| C.70.01.02.11 |  | Descolmatación Dique A3-D-01 | 4d | 2023-05-26 | 2023-05-29 | C.80.02.17 SS+1d | 105d | 0d | HH [253.31 h]; HM [163.48 h] | S4 |
| C.70.01.02.19 |  | Relleno no estructural Dique A3-D-01 | 2d | 2023-05-27 | 2023-05-28 | C.70.01.02.11 SS+1d | 105d | 0d | HH [75.72 h]; HM [36.15 h] | S4 |
| C.70.01.02.12 |  | Descolmatación Dique A3-D-02 - Sector 1 | 4d | 2023-06-03 | 2023-06-06 | C.80.02.18 | 77d | 0d | HH [272.7 h]; HM [175.99 h] | S3 |
| C.70.01.02.17 |  | Descolmatación Dique A3-I-03 - Sector 1 | 7d | 2023-06-07 | 2023-06-13 | C.80.02.23 | 48d | 0d | HH [445.67 h]; HM [287.61 h] | S2 |
| C.70.01.02.20 |  | Relleno no estructural Dique A3-D-02 - Sector 1 | 2d | 2023-06-07 | 2023-06-08 | C.70.01.02.12 | 77d | 0d | HH [69.91 h]; HM [33.37 h] | S3 |
| C.70.01.02.18 |  | Descolmatación Dique A3-I-03 - Sector 2 | 8d | 2023-06-09 | 2023-06-16 | C.80.02.24 | 38d | 0d | HH [500.01 h]; HM [322.68 h] | S1 |
| C.70.01.02.16 |  | Descolmatación Dique A3-I-02 | 8d | 2023-06-10 | 2023-06-17 | C.80.02.22 | 0d |  | HH [529.19 h]; HM [341.51 h] | S3 |
| C.70.01.02.14 |  | Descolmatación Dique A3-D-02 - Sector 3 | 9d | 2023-06-12 | 2023-06-20 | C.80.02.20 | 2d | 0d | HH [580.4 h]; HM [374.56 h] | S1 |
| C.70.01.02.25 |  | Relleno no estructural Dique A3-I-03 - Sector 1 | 3d | 2023-06-14 | 2023-06-16 | C.70.01.02.17 | 48d | 0d | HH [138.1 h]; HM [65.93 h] | S2 |
| C.70.01.02.26 |  | Relleno no estructural Dique A3-I-03 - Sector 2 | 4d | 2023-06-17 | 2023-06-20 | C.70.01.02.18 | 38d | 0d | HH [162.57 h]; HM [77.61 h] | S1 |
| C.70.01.02.24 |  | Relleno no estructural Dique A3-I-02 | 2d | 2023-06-18 | 2023-06-19 | C.70.01.02.16 | 0d |  | HH [69.91 h]; HM [33.37 h] | S3 |
| C.70.01.02.15 |  | Descolmatación Dique A3-I-01 | 13d | 2023-06-20 | 2023-07-02 | C.80.02.21 | 58d | 0d | HH [883.18 h]; HM [569.96 h] | S4 |
| C.70.01.02.22 |  | Relleno no estructural Dique A3-D-02 - Sector 3 | 4d | 2023-06-21 | 2023-06-24 | C.70.01.02.14 | 2d | 0d | HH [162.57 h]; HM [77.61 h] | S1 |
| C.70.01.02.23 |  | Relleno no estructural Dique A3-I-01 | 2d | 2023-07-03 | 2023-07-04 | C.70.01.02.15 | 58d | 0d | HH [72.46 h]; HM [34.59 h] | S4 |
|  | 02 | **CAMINOS PROVISIONALES** |  | 2023-05-18 | 2023-06-11 |  |  |  |  |  |
|  | 01 | **MEJORAMIENTO DE VIAS** |  | 2023-05-18 | 2023-06-11 |  |  |  |  |  |
|  | 01 | **MEJORAMIENTO DE VIAS EXISTENTES** |  | 2023-05-18 | 2023-05-31 |  |  |  |  |  |
| C.70.02.01.01.11 |  | Mejoramiento de vías - Vía Acceso AN-879 | 4d | 2023-05-18 | 2023-05-21 | M.10.01.02.11 SS | 0d |  | HH [172.72 h]; HM [52.43 h] | S5 |
| C.70.02.01.01.14 |  | Mejoramiento de vías - EMPALME CHACHAPOYAS | 2d | 2023-05-22 | 2023-05-23 | C.70.02.01.01.11 | 0d |  | HH [80.06 h]; HM [24.3 h] | S5 |
| C.70.02.01.01.13 |  | Mejoramiento de vías - EMPALME CANAL - DME-3A | 4d | 2023-05-24 | 2023-05-27 | C.70.02.01.01.14, C.70.01.01.11 | 167d | 0d | HH [222.38 h]; HM [67.51 h] | S5 |
| C.70.02.01.01.12 |  | Mejoramiento de vías - FA-07 --AN-879 | 4d | 2023-05-28 | 2023-05-31 | C.70.02.01.01.13 | 167d | 0d | HH [208.3 h]; HM [63.23 h] | S5 |

| ID | WBS | Activity | Type | Duration | Start | Finish | Predecessors | Total float | Free float | Resources |
| --- | --- | --- | --- | --- | --- | --- | --- | --- | --- | --- |
|  | 02 | **REPOSICIÓN DE ESTRUCTURAS EXISTENTES** |  |  | 2023-06-02 | 2023-06-07 |  |  |  |  |
|  | 01 | **PUNTO DE AGUA 1** |  |  | 2023-06-02 | 2023-06-03 |  |  |  |  |
| C.70.02.01.02.01.11 |  | Suministro de paneles de C°A° |  | 2d | 2023-06-02 | 2023-06-03 | C.80.02.11 | 175d |  | HH [5.01 h]; HM [1.34 h] |
|  | 02 | **PUNTO DE AGUA 2** |  |  | 2023-06-03 | 2023-06-03 |  |  |  |  |
| C.70.02.01.02.02.11 |  | Suministro de paneles de C°A° |  | 1d | 2023-06-03 | 2023-06-03 | C.80.02.12 | 175d |  | HH [99.61 h]; HM [36.33 h] |
|  | 03 | **PUNTO DE AGUA 3** |  |  | 2023-06-05 | 2023-06-07 |  |  |  |  |
| C.70.02.01.02.03.11 |  | Reposición de pase agua tubo HDPE 36" |  | 3d | 2023-06-05 | 2023-06-07 | C.80.02.13 | 167d | 0d | HH [108.76 h]; HM [38.35 h] |
| C.70.02.01.02.03.12 |  | Reposición de pase agua tubo HDPE 18" |  | 0d | 2023-06-05 | 2023-06-05 | C.80.02.13 | 170d | 3d |  |
|  | 03 | **CABEZAL DE ENTRADA Y SALIDA** |  |  | 2023-06-08 | 2023-06-11 |  |  |  |  |
| C.70.02.01.03.11 |  | Encofrado recto cabeza de entrada |  | 1d | 2023-06-08 | 2023-06-08 | C.70.02.01.02.03.11, C.70.02.01.02.03.12 | 167d | 0d | HH [24.32 h]; HM [9.35 h] |
| C.70.02.01.03.12 |  | Concreto cabezal de entrada |  | 1d | 2023-06-09 | 2023-06-09 | C.70.02.01.03.11 | 167d | 0d | HH [35.51 h]; HM [5.67 h] |
| C.70.02.01.03.14 |  | Encofrado recto cabeza de salida |  | 1d | 2023-06-09 | 2023-06-09 | C.70.02.01.03.11 | 167d | 0d | HH [12.38 h]; HM [4.76 h] |
| C.70.02.01.03.13 |  | Desconfrado de cabezal de entrada |  | 1d | 2023-06-10 | 2023-06-10 | C.70.02.01.03.12 | 167d | 0d | HH [24.32 h]; HM [9.35 h] |
| C.70.02.01.03.15 |  | Concreto cabezal de salida |  | 1d | 2023-06-10 | 2023-06-10 | C.70.02.01.03.12, C.70.02.01.03.14 | 167d | 0d | HH [16.25 h]; HM [2.6 h] |
| C.70.02.01.03.16 |  | Desconfrado de cabezal de salida |  | 1d | 2023-06-11 | 2023-06-11 | C.70.02.01.03.13, C.70.02.01.03.15 | 167d |  | HH [12.38 h]; HM [4.76 h] |
|  | 03 | **PLANTACIÓN Y PAISAJISMO** |  |  | 2023-10-06 | 2023-10-20 |  |  |  |  |
|  | 01 | **MOVIMIENTO DE TIERRAS** |  |  | 2023-10-06 | 2023-10-09 |  |  |  |  |
| C.70.03.01.11 |  | Excavación manual para instalación de bordillos |  | 3d | 2023-10-06 | 2023-10-08 | C.90.02.01.12 | 26d | 0d | HH [20.79 h] |
| C.70.03.01.13 |  | Eliminación material excedente | level of effort | 4d | 2023-10-06 | 2023-10-09 | C.70.03.01.11 SS | 26d | 0d | HH [3.21 h]; HM [2.71 h] |
| C.70.03.01.12 |  | Excavación para mejoramiento con tierra vegetal |  | 1d | 2023-10-09 | 2023-10-09 | C.70.03.01.11, C.70.03.01.13 FF | 26d | 0d | HH [1.6 h]; HM [0.76 h] |
|  | 02 | **PAVIMENTOS, RECUBRIMIENTOS Y BORDILLOS** |  |  | 2023-10-10 | 2023-10-19 |  |  |  |  |
| C.70.03.02.11 |  | Piso de gravilla |  | 2d | 2023-10-10 | 2023-10-11 | C.70.03.01.12 | 26d | 0d | HH [44.55 h]; HM [10.43 h] |
| C.70.03.02.13 |  | Bordillos de piedra de lugar |  | 5d | 2023-10-12 | 2023-10-16 | C.70.03.02.11 | 26d | 0d | HH [167.16 h]; HM [1.85 h] |
| C.70.03.02.12 |  | Recubrimiento de piedra de lugar |  | 3d | 2023-10-17 | 2023-10-19 | C.70.03.02.13 | 26d | 0d | HH [63.19 h] |

| ID | WBS | Activity | Type | Duration | Start | Finish | Predecessors | Total float | Free float | Resources | SECTOR |
| --- | --- | --- | --- | --- | --- | --- | --- | --- | --- | --- | --- |
|  | 04 | **INSTALACIÓN DE ALCORQUES** |  |  | 2023-10-20 | 2023-10-20 |  |  |  |  |  |
| C.70.03.03.11 |  | Instalación de alcorques de piedra |  | 1d | 2023-10-20 | 2023-10-20 | C.70.03.02.12 | 26d | 0d | HH [7.5 h] |  |
|  | 05 | **MOBILIARIO Y EQUIPAMIENTO URBANO** |  |  | 2023-10-21 | 2023-11-03 |  |  |  |  |  |
|  | 01 | **MOBILIARIOS, BARANDAS Y ESCALERAS** |  |  | 2023-10-21 | 2023-11-03 |  |  |  |  |  |
| C.70.05.01.11 |  | Escalera de concreto sobre enrocado |  | 2d | 2023-10-21 | 2023-10-22 | C.70.03.03.11 | 26d | 0d | HH [329.05 h]; HM [191.73 h] |  |
| C.70.05.01.12 |  | Baranda de madera eucalipto con soga |  | 2d | 2023-10-23 | 2023-10-24 | C.70.05.01.11 | 26d | 0d | HH [99.9 h]; HM [48 h] |  |
| C.70.05.01.13 |  | Tachos de basura |  | 2d | 2023-10-25 | 2023-10-26 | C.70.05.01.12 | 26d | 0d | HH [46.81 h]; HM [2.62 h] |  |
| C.70.05.01.14 |  | Bancas de concreto |  | 2d | 2023-10-27 | 2023-10-28 | C.70.05.01.13 | 26d | 0d | HH [71.55 h]; HM [5.31 h] |  |
| C.70.05.01.15 |  | Postes de iluminación |  | 2d | 2023-10-29 | 2023-10-30 | C.70.05.01.14 | 26d | 0d | HH [43.47 h]; HM [2.24 h] |  |
| C.70.05.01.16 |  | Señalética informativa |  | 2d | 2023-10-31 | 2023-11-01 | C.70.05.01.15 | 26d | 0d | HH [43.47 h]; HM [2.24 h] |  |
| C.70.05.01.17 |  | Bolardos de Piedra |  | 2d | 2023-11-02 | 2023-11-03 | C.70.05.01.16, C.90.02.02.12 FF | 26d |  | HH [20 h]; HM [5 h] |  |
|  | 10 | **CUERPOS DE TERRAPLEN** |  |  | 2023-05-23 | 2023-10-19 |  |  |  |  |  |
|  | 01 | **DIQUE A3-D-01** |  |  | 2023-05-28 | 2023-08-08 |  |  |  |  |  |
| C.70.10.01.11 |  | Excavación en terreno natural con equipo |  | 9d | 2023-05-28 | 2023-06-05 | C.70.01.02.19 SS+1d | 105d | 0d | EXCAVACIONES [6167.17]; HH [382.36 h]; HM [246.69 h] | S4 |
| C.70.10.01.13 |  | Perfilado y compatación en zona de corte |  | 8d | 2023-06-06 | 2023-06-13 | C.70.10.01.11 | 109d | 0d | HH [649.14 h]; HM [297.71 h] | S4 |
| C.70.10.01.19 |  | Preparación de fundación cuerpo de dique | level of effort | 12d | 2023-06-06 | 2023-06-17 | C.70.10.01.13 SS | 109d | 0d | HH [75.35 h]; HM [38.31 h] | S4 |
| C.70.10.01.14 |  | Conformación de cuerpo de dique |  | 4d | 2023-06-14 | 2023-06-17 | C.70.10.01.13, C.70.10.01.19 FF | 109d | 0d | RELLENOS [1639.2]; HH [552.9 h]; HM [277.19 h] | S4 |
| C.70.10.01.12 |  | Excavación de uña con equipo |  | 4d | 2023-06-18 | 2023-06-21 | C.70.10.01.14 | 109d | 0d | EXCAVACIONES [2325.01]; HH [159.96 h]; HM [154.85 h] | S4 |
| C.70.10.01.16 |  | Instalación de geotextil no tejido |  | 36d | 2023-06-22 | 2023-07-27 | C.70.10.01.12 | 109d | 0d | HH [417.09 h] | S4 |
| C.70.10.01.17 |  | Colocación y acomodo de roca en uña |  | 13d | 2023-06-22 | 2023-07-04 | C.70.10.01.16 SS | 109d | 0d | ENROCADOS [2325.01]; HH [794.23 h]; HM [193.67 h] | S4 |
| C.70.10.01.18 |  | Colocación y acomodo de roca en talud |  | 29d | 2023-07-05 | 2023-08-02 | C.70.10.01.17 | 109d | 0d | ENROCADOS [3493.37]; HH [1790.35 h]; HM [436.67 h] | S4 |
| C.70.10.01.15 |  | Conformación de corona de dique |  | 6d | 2023-08-03 | 2023-08-08 | C.70.10.01.18, C.70.10.01.16 | 109d |  | HH [399.16 h]; HM [198.73 h] | S4 |
|  | 02 | **DIQUE A3-D-02** |  |  | 2023-05-23 | 2023-10-19 |  |  |  |  |  |
|  | 1 | **SECTOR 1** |  |  | 2023-06-09 | 2023-09-09 |  |  |  |  |  |
| C.70.10.02.1.11 |  | Excavación en terreno natural con equipo |  | 21d | 2023-06-09 | 2023-06-29 | C.70.01.02.20 | 77d | 0d | EXCAVACIONES [15433.6]; HH [956.88 h]; HM [617.34 h] | S3 |
| C.70.10.02.1.13 |  | Perfilado y compatación en zona de corte |  | 7d | 2023-06-30 | 2023-07-06 | C.70.10.02.1.11 | 77d | 0d | HH [570.01 h]; HM [261.42 h] | S3 |
| C.70.10.02.1.19 |  | Preparación de fundación cuerpo de dique | level of effort | 11d | 2023-06-30 | 2023-07-10 | C.70.10.02.1.13 SS | 77d | 0d | HH [60.28 h]; HM [30.65 h] | S3 |
| C.70.10.02.1.14 |  | Conformación de cuerpo de dique |  | 4d | 2023-07-07 | 2023-07-10 | C.70.10.02.1.13, C.70.10.02.1.19 FF | 77d | 0d | RELLENOS [1487.3]; HH [501.66 h]; HM [251.5 h] | S3 |
| C.70.10.02.1.12 |  | Excavación de uña con equipo |  | 5d | 2023-07-11 | 2023-07-15 | C.70.10.02.1.14 | 77d | 0d | EXCAVACIONES [3144.9]; HH [216.37 h]; HM [209.45 h] | S3 |
| C.70.10.02.1.16 |  | Instalación de geotextil no tejido |  | 32d | 2023-07-16 | 2023-08-16 | C.70.10.02.1.12 | 77d | 0d | HH [375.63 h] | S3 |
| C.70.10.02.1.17 |  | Colocación y acomodo de roca en uña |  | 18d | 2023-07-16 | 2023-08-02 | C.70.10.02.1.16 SS | 77d | 0d | ENROCADOS [3144.9]; HH [1074.3 h]; HM [261.97 h] | S3 |
| C.70.10.02.1.18 |  | Colocación y acomodo de roca en talud |  | 32d | 2023-08-03 | 2023-09-03 | C.70.10.02.1.17 | 77d | 0d | ENROCADOS [3901.4]; HH [1999.47 h]; HM [487.68 h] | S3 |
| C.70.10.02.1.15 |  | Conformación de corona de dique |  | 6d | 2023-09-04 | 2023-09-09 | C.70.10.02.1.18, C.70.10.02.1.16 | 77d |  | HH [384.52 h]; HM [191.44 h] | S3 |

| ID | WBS | Activity | Type | Duration | Start | Finish | Predecessors | Total float | Free float | Resources | SECTOR |
| --- | --- | --- | --- | --- | --- | --- | --- | --- | --- | --- | --- |
|  | 2 | **SECTOR 2** |  |  | 2023-05-23 | 2023-09-17 |  |  |  |  |  |
| C.70.10.02.2.11 |  | Excavación en terreno natural con equipo |  | 16d | 2023-05-23 | 2023-06-07 | C.70.01.02.21 SS+1d | 69d | 0d | EXCAVACIONES [17674.7]; HH [1095.83 h]; HM [706.99 h] | S2 |
| C.70.10.02.2.13 |  | Perfilado y compatación en zona de corte |  | 14d | 2023-06-08 | 2023-06-21 | C.70.10.02.2.11 | 69d | 0d | HH [1785.91 h]; HM [819.06 h] | S2 |
| C.70.10.02.2.19 |  | Preparación de fundación cuerpo de dique | level of effort | 19d | 2023-06-08 | 2023-06-26 | C.70.10.02.2.13 SS | 69d | 0d | HH [117.69 h]; HM [59.84 h] | S2 |
| C.70.10.02.2.14 |  | Conformación de cuerpo de dique |  | 5d | 2023-06-22 | 2023-06-26 | C.70.10.02.2.13, C.70.10.02.2.19 FF | 69d | 0d | RELLENOS [3362.3]; HH [1134.1 h]; HM [568.56 h] | S2 |
| C.70.10.02.2.12 |  | Excavación de uña con equipo |  | 7d | 2023-06-27 | 2023-07-03 | C.70.10.02.2.14 | 69d | 0d | EXCAVACIONES [6494.4]; HH [446.81 h]; HM [432.53 h] | S2 |
| C.70.10.02.2.16 |  | Instalación de geotextil no tejido |  | 66d | 2023-07-04 | 2023-09-07 | C.70.10.02.2.12 | 69d | 0d | HH [780.31 h] | S2 |
| C.70.10.02.2.17 |  | Colocación y acomodo de roca en uña |  | 24d | 2023-07-04 | 2023-07-27 | C.70.10.02.2.16 SS | 69d | 0d | ENROCADOS [6494.4]; HH [2218.49 h]; HM [540.98 h] | S2 |
| C.70.10.02.2.18 |  | Colocación y acomodo de roca en talud |  | 46d | 2023-07-28 | 2023-09-11 | C.70.10.02.2.17 | 69d | 0d | ENROCADOS [8322.3]; HH [4265.18 h]; HM [1040.29 h] | S2 |
| C.70.10.02.2.15 |  | Conformación de corona de dique |  | 6d | 2023-09-12 | 2023-09-17 | C.70.10.02.2.18, C.70.10.02.2.16 | 69d |  | HH [781.74 h]; HM [389.21 h] | S2 |
|  | 3 | **SECTOR 3** |  |  | 2023-06-25 | 2023-10-19 |  |  |  |  |  |
| C.70.10.02.3.10 |  | Excavación en terreno natural con equipo |  | 18d | 2023-06-25 | 2023-07-12 | C.70.01.02.22 | 2d | 0d | EXCAVACIONES [20177.7]; HH [1251.02 h]; HM [807.11 h] | S1 |
| C.70.10.02.3.12 |  | Perfilado y compatación en zona de corte |  | 13d | 2023-07-13 | 2023-07-25 | C.70.10.02.3.10 | 37d | 0d | HH [1686.27 h]; HM [773.36 h] | S1 |
| C.70.10.02.3.18 |  | Preparación de fundación cuerpo de dique | level of effort | 17d | 2023-07-13 | 2023-07-29 | C.70.10.02.3.12 SS | 37d | 0d | HH [128.29 h]; HM [65.23 h] | S1 |
| C.70.10.02.3.13 |  | Conformación de cuerpo de dique |  | 4d | 2023-07-26 | 2023-07-29 | C.70.10.02.3.12, C.70.10.02.3.18 FF | 37d | 0d | RELLENOS [2091.3]; HH [705.39 h]; HM [353.64 h] | S1 |
| C.70.10.02.3.11 |  | Excavación de uña con equipo |  | 7d | 2023-07-30 | 2023-08-05 | C.70.10.02.3.13 | 37d | 0d | EXCAVACIONES [7079.69]; HH [487.08 h]; HM [471.51 h] | S1 |
| C.70.10.02.3.15 |  | Instalación de geotextil no tejido |  | 62d | 2023-08-06 | 2023-10-06 | C.70.10.02.3.11 | 37d | 0d | HH [732.3 h] | S1 |
| C.70.10.02.3.16 |  | Colocación y acomodo de roca en uña |  | 26d | 2023-08-06 | 2023-08-31 | C.70.10.02.3.15 SS | 37d | 0d | ENROCADOS [7079.69]; HH [2418.42 h]; HM [589.74 h] | S1 |
| C.70.10.02.3.17 |  | Colocación y acomodo de roca en talud |  | 43d | 2023-09-01 | 2023-10-13 | C.70.10.02.3.16, C.90.02.07.13 FF, C.90.02.07.14 | 37d | 0d | ENROCADOS [7799.43]; HH [3997.21 h]; HM [974.93 h] | S1 |
| C.70.10.02.3.14 |  | Conformación de corona de dique |  | 6d | 2023-10-14 | 2023-10-19 | C.70.10.02.3.17, C.70.10.02.3.15, C.90.02.07.12 FF, C.90.02.07.11 FF | 37d |  | HH [850.2 h]; HM [423.29 h] | S1 |
|  | 03 | **DIQUE A3-I-01** |  |  | 2023-07-05 | 2023-09-27 |  |  |  |  |  |
| C.70.10.03.11 |  | Excavación en terreno natural con equipo |  | 18d | 2023-07-05 | 2023-07-22 | C.70.01.02.23 | 58d | 0d | EXCAVACIONES [13764.5]; HH [853.4 h]; HM [550.58 h] | S4 |
| C.70.10.03.13 |  | Perfilado y compatación en zona de corte |  | 7d | 2023-07-23 | 2023-07-29 | C.70.10.03.11 | 59d | 0d | HH [568.42 h]; HM [260.69 h] | S4 |
| C.70.10.03.19 |  | Preparación de fundación cuerpo de dique | level of effort | 16d | 2023-07-23 | 2023-08-07 | C.70.10.03.13 SS | 59d | 0d | HH [100.57 h]; HM [51.14 h] | S4 |
| C.70.10.03.14 |  | Conformación de cuerpo de dique |  | 9d | 2023-07-30 | 2023-08-07 | C.70.10.03.13, C.70.10.03.19 FF | 59d | 0d | RELLENOS [578.56]; HH [1137.26 h]; HM [570.15 h] | S4 |
| C.70.10.03.12 |  | Excavación de uña con equipo |  | 4d | 2023-08-08 | 2023-08-11 | C.70.10.03.14, C.90.02.07.16 FF, C.90.02.07.15 FF | 59d | 0d | EXCAVACIONES [2275.54]; HH [156.56 h]; HM [151.55 h] | S4 |
| C.70.10.03.16 |  | Instalación de geotextil no tejido |  | 35d | 2023-08-12 | 2023-09-15 | C.70.10.03.12 | 59d | 0d | HH [408.93 h] | S4 |
| C.70.10.03.17 |  | Colocación y acomodo de roca en uña |  | 13d | 2023-08-12 | 2023-08-24 | C.70.10.03.16 SS | 59d | 0d | ENROCADOS [2275.54]; HH [777.33 h]; HM [189.55 h] | S4 |
| C.70.10.03.18 |  | Colocación y acomodo de roca en talud |  | 28d | 2023-08-25 | 2023-09-21 | C.70.10.03.17 | 59d | 0d | ENROCADOS [3426.26]; HH [1755.96 h]; HM [428.28 h] | S4 |
| C.70.10.03.15 |  | Conformación de corona de dique |  | 6d | 2023-09-22 | 2023-09-27 | C.70.10.03.18, C.70.10.03.16 | 59d |  | HH [391.04 h]; HM [194.69 h] | S4 |

| ID | WBS | Activity | Type | Duration | Start | Finish | Predecessors | Total float | Free float | Resources | SECTOR |
| --- | --- | --- | --- | --- | --- | --- | --- | --- | --- | --- | --- |
|  | 04 | **DIQUE A3-I-02** |  |  | 2023-06-20 | 2023-09-21 |  |  |  |  |  |
| C.70.10.04.11 |  | Excavación en terreno natural con equipo |  | 25d | 2023-06-20 | 2023-07-14 | C.70.01.02.24 | 0d |  | EXCAVACIONES [18781.3]; HH [1164.44 h]; HM [751.25 h] | S3 |
| C.70.10.04.13 |  | Perfilado y compatación en zona de corte |  | 8d | 2023-07-15 | 2023-07-22 | C.70.10.04.11 | 26d | 0d | HH [707.84 h]; HM [324.63 h] | S3 |
| C.70.10.04.19 |  | Preparación de fundación cuerpo de dique | level of effort | 8d | 2023-07-15 | 2023-07-22 | C.70.10.04.13 SS | 26d | 0d | HH [41.76 h]; HM [21.23 h] | S3 |
| C.70.10.04.12 |  | Excavación de uña con equipo |  | 5d | 2023-07-23 | 2023-07-27 | C.70.10.04.14 | 26d | 0d | EXCAVACIONES [3101.07]; HH [213.35 h]; HM [206.53 h] | S3 |
| C.70.10.04.14 |  | Conformación de cuerpo de dique |  | 0d | 2023-07-23 | 2023-07-23 | C.70.10.04.13, C.70.10.04.19 FF | 26d | 0d |  | S3 |
| C.70.10.04.16 |  | Instalación de geotextil no tejido |  | 31d | 2023-07-28 | 2023-08-27 | C.70.10.04.12 | 26d | 0d | HH [368.28 h] | S3 |
| C.70.10.04.17 |  | Colocación y acomodo de roca en uña |  | 17d | 2023-07-28 | 2023-08-13 | C.70.10.04.16 SS | 26d | 0d | ENROCADOS [3101.07]; HH [1059.32 h]; HM [258.32 h] | S3 |
| C.70.10.04.18 |  | Colocación y acomodo de roca en talud |  | 32d | 2023-08-14 | 2023-09-14 | C.70.10.04.17 | 26d | 0d | ENROCADOS [3837.2]; HH [1966.57 h]; HM [479.65 h] | S3 |
| C.70.10.04.15 |  | Conformación de corona de dique |  | 7d | 2023-09-15 | 2023-09-21 | C.70.10.04.18, C.70.10.04.16 | 26d | 0d | HH [463.56 h]; HM [230.79 h] | S3 |
|  | 05 | **DIQUE A3-I-03** |  |  | 2023-06-17 | 2023-10-18 |  |  |  |  |  |
|  | 1 | **SECTOR 1** |  |  | 2023-06-17 | 2023-10-08 |  |  |  |  |  |
| C.70.10.05.1.11 |  | Excavación en terreno natural con equipo |  | 16d | 2023-06-17 | 2023-07-02 | C.70.01.02.25 | 48d | 0d | EXCAVACIONES [17723]; HH [1098.83 h]; HM [708.92 h] | S2 |
| C.70.10.05.1.13 |  | Perfilado y compatación en zona de corte |  | 12d | 2023-07-03 | 2023-07-14 | C.70.10.05.1.11 | 48d | 0d | HH [1555.17 h]; HM [713.23 h] | S2 |
| C.70.10.05.1.19 |  | Preparación de fundación cuerpo de dique | level of effort | 14d | 2023-07-03 | 2023-07-16 | C.70.10.05.1.13 SS | 48d | 0d | HH [137.16 h]; HM [69.74 h] | S2 |
| C.70.10.05.1.14 |  | Conformación de cuerpo de dique |  | 2d | 2023-07-15 | 2023-07-16 | C.70.10.05.1.13, C.70.10.05.1.19 FF | 48d | 0d | RELLENOS [1359.4]; HH [458.53 h]; HM [229.87 h] | S2 |
| C.70.10.05.1.12 |  | Excavación de uña con equipo |  | 7d | 2023-07-17 | 2023-07-23 | C.70.10.05.1.14 | 48d | 0d | EXCAVACIONES [6494.4]; HH [446.81 h]; HM [432.53 h] | S2 |
| C.70.10.05.1.16 |  | Instalación de geotextil no tejido |  | 66d | 2023-07-24 | 2023-09-27 | C.70.10.05.1.12 | 48d | 0d | ENROCADOS [10055.1]; HH [779.27 h] | S2 |
| C.70.10.05.1.17 |  | Colocación y acomodo de roca en uña |  | 24d | 2023-07-24 | 2023-08-16 | C.70.10.05.1.16 SS | 48d | 0d | ENROCADOS [6494.4]; HH [2218.49 h]; HM [540.98 h] | S2 |
| C.70.10.05.1.18 |  | Colocación y acomodo de roca en talud |  | 47d | 2023-08-17 | 2023-10-02 | C.70.10.05.1.17 | 48d | 0d | HH [4418.21 h]; HM [1077.61 h] | S2 |
| C.70.10.05.1.15 |  | Conformación de corona de dique |  | 6d | 2023-10-03 | 2023-10-08 | C.70.10.05.1.18 | 48d |  | HH [774.8 h]; HM [385.75 h] | S2 |
|  | 2 | **SECTOR 2** |  |  | 2023-06-21 | 2023-10-18 |  |  |  |  |  |
| C.70.10.05.2.11 |  | Excavación en terreno natural con equipo |  | 15d | 2023-06-21 | 2023-07-05 | C.70.01.02.26 | 38d | 0d | EXCAVACIONES [16797.4]; HH [1041.44 h]; HM [671.9 h] | S1 |
| C.70.10.05.2.13 |  | Perfilado y compatación en zona de corte |  | 13d | 2023-07-06 | 2023-07-18 | C.70.10.05.2.11 | 38d | 0d | HH [1716.07 h]; HM [787.02 h] | S1 |
| C.70.10.05.2.19 |  | Preparación de fundación cuerpo de dique | level of effort | 20d | 2023-07-06 | 2023-07-25 | C.70.10.05.2.13 SS | 38d | 0d | HH [153.89 h]; HM [78.25 h] | S1 |
| C.70.10.05.2.14 |  | Conformación de cuerpo de dique |  | 7d | 2023-07-19 | 2023-07-25 | C.70.10.05.2.13, C.70.10.05.2.19 FF | 38d | 0d | RELLENOS [4286.7]; HH [1445.9 h]; HM [724.88 h] | S1 |
| C.70.10.05.2.12 |  | Excavación de uña con equipo |  | 8d | 2023-07-26 | 2023-08-02 | C.70.10.05.2.14 | 38d | 0d | EXCAVACIONES [7286.4]; HH [501.3 h]; HM [485.27 h] | S1 |
| C.70.10.05.2.16 |  | Instalación de geotextil no tejido |  | 64d | 2023-08-03 | 2023-10-05 | C.70.10.05.2.12 | 38d | 0d | ENROCADOS [9766.68]; HH [756.92 h] | S1 |
| C.70.10.05.2.17 |  | Colocación y acomodo de roca en uña |  | 27d | 2023-08-03 | 2023-08-29 | C.70.10.05.2.16 SS | 38d | 0d | ENROCADOS [7286.4]; HH [2489.03 h]; HM [606.96 h] | S1 |
| C.70.10.05.2.18 |  | Colocación y acomodo de roca en talud |  | 44d | 2023-08-30 | 2023-10-12 | C.70.10.05.2.17 | 38d | 0d | HH [4111.84 h]; HM [1002.89 h] | S1 |
| C.70.10.05.2.15 |  | Conformación de corona de dique |  | 6d | 2023-10-13 | 2023-10-18 | C.70.10.05.2.18 | 38d |  | HH [868.08 h]; HM [432.19 h] | S1 |

| ID | WBS | Activity | Type | Duration | Start | Finish | Predecessors | Total float | Free float | Resources |
| --- | --- | --- | --- | --- | --- | --- | --- | --- | --- | --- |
|  | 11 | **SUPERFICIES DE TERRAPLEN** |  |  | 2023-06-27 | 2023-07-28 |  |  |  |  |
|  | 01 | **RAMPA A3-RA-D-01** |  |  | 2023-06-27 | 2023-06-29 |  |  |  |  |
| C.70.11.01.11 |  | Excavación en terreno natural con equipo |  | 1d | 2023-06-27 | 2023-06-27 | C.70.10.02.2.14 | 149d | 0d | HH [15.39 h]; HM [9.93 h] |
| C.70.11.01.12 |  | Conformación de cuerpo de dique |  | 0d | 2023-06-28 | 2023-06-28 | C.70.11.01.11 | 149d | 0d |  |
| C.70.11.01.13 |  | Conformación de coronación de rampas |  | 2d | 2023-06-28 | 2023-06-29 | C.70.11.01.12 | 149d |  | HH [51.11 h]; HM [26.64 h] |
|  | 02 | **RAMPA A3-RA-I-01** |  |  | 2023-07-26 | 2023-07-28 |  |  |  |  |
| C.70.11.02.11 |  | Excavación en terreno natural con equipo |  | 1d | 2023-07-26 | 2023-07-26 | C.70.10.05.2.14 | 120d | 0d | HH [11.1 h]; HM [7.16 h] |
| C.70.11.02.12 |  | Conformación de cuerpo de dique |  | 0d | 2023-07-27 | 2023-07-27 | C.70.11.02.11 | 120d | 0d |  |
| C.70.11.02.13 |  | Conformación de coronación de rampas |  | 2d | 2023-07-27 | 2023-07-28 | C.70.11.02.12 | 120d |  | HH [45.02 h]; HM [23.51 h] |
|  | 60 | **TRABAJOS DE RENOVACIÓN** |  |  | 2023-07-05 | 2023-11-25 |  |  |  |  |
|  | 02 | **REPARACION DE SERVICIOS EXISTENTES** |  |  | 2023-07-05 | 2023-11-25 |  |  |  |  |
|  | 01 | **REPOSICION CANAL 1** |  |  | 2023-07-15 | 2023-11-25 |  |  |  |  |
|  | 01 | **MOVIMIENTO DE TIERRAS** |  |  | 2023-07-15 | 2023-11-25 |  |  |  |  |
| C.60.02.01.01.11 |  | Excavación en terreno natural con equipo |  | 10d | 2023-07-15 | 2023-07-24 | C.80.02.14, C.70.10.02.3.10, C.70.10.04.11 | 0d |  | HH [213.93 h]; HM [138.02 h] |
| C.60.02.01.01.12 |  | Relleno estructural para obras de arte con material propio |  | 51d | 2023-10-06 | 2023-11-25 | C.60.02.01.02.17 | 0d |  | HH [1475.72 h]; HM [654.5 h] |
|  | 02 | **OBRAS DE CONCRETO** |  |  | 2023-07-25 | 2023-10-06 |  |  |  |  |
| C.60.02.01.02.13 |  | Concreto - solado |  | 6d | 2023-07-25 | 2023-07-30 | C.60.02.01.01.11 | 0d |  | HH [352.7 h]; HM [43.54 h] |
| C.60.02.01.02.12 |  | Acero de refuerzo |  | 20d | 2023-07-31 | 2023-08-19 | C.60.02.01.02.13 | 0d |  | HH [4681.03 h]; HM [3020.02 h] |
| C.60.02.01.02.15 |  | Junta Water Stop | level of effort | 37d | 2023-07-31 | 2023-09-05 | C.60.02.01.02.12 SS | 0d |  | HH [328.65 h] |
| C.60.02.01.02.11 |  | Encofrado recto |  | 17d | 2023-08-20 | 2023-09-05 | C.60.02.01.02.12, C.60.02.01.02.15 FF | 0d |  | HH [6427.77 h]; HM [2472.02 h] |
| C.60.02.01.02.14 |  | Concreto canal |  | 13d | 2023-09-06 | 2023-09-18 | C.60.02.01.02.11 | 0d |  | HH [1739.7 h]; HM [188.66 h] |
| C.60.02.01.02.17 |  | Desencofrado |  | 17d | 2023-09-19 | 2023-10-05 | C.60.02.01.02.14 | 0d |  | HH [6427.77 h]; HM [2472.02 h] |
| C.60.02.01.02.16 |  | Mamposteria de piedra |  | 1d | 2023-10-06 | 2023-10-06 | C.60.02.01.02.17 | 50d |  | HH [27.02 h]; HM [0.46 h] |
|  | 02 | **REPOSICION CANAL 3** |  |  | 2023-07-23 | 2023-08-15 |  |  |  |  |
|  | 01 | **MOVMIENTO DE TIERRAS** |  |  | 2023-07-23 | 2023-08-15 |  |  |  |  |
| C.60.02.02.01.11 |  | Excavación en terreno natural con equipo |  | 1d | 2023-07-23 | 2023-07-23 | C.80.02.15, C.70.10.01.11, C.70.10.03.11 | 102d | 0d | HH [17.2 h]; HM [11.1 h] |
| C.60.02.02.01.12 |  | Relleno estructural para obras de arte con material propio |  | 2d | 2023-08-14 | 2023-08-15 | C.60.02.02.02.17 | 102d |  | HH [25.75 h]; HM [11.42 h] |

| ID | WBS | Activity | Type | Duration | Start | Finish | Predecessors | Total float | Free float | Resources |
| --- | --- | --- | --- | --- | --- | --- | --- | --- | --- | --- |
|  | 02 | **OBRAS DE CONCRETO** |  |  | 2023-07-24 | 2023-08-14 |  |  |  |  |
| C.60.02.02.02.13 |  | Concreto - solado |  | 2d | 2023-07-24 | 2023-07-25 | C.60.02.02.01.11 | 102d | 0d | HH [94.24 h]; HM [11.63 h] |
| C.60.02.02.02.12 |  | Malla Electrosoldada |  | 9d | 2023-07-26 | 2023-08-03 | C.60.02.02.02.13 | 102d | 0d | HH [123.55 h] |
| C.60.02.02.02.15 |  | Junta Water Stop | level of effort | 13d | 2023-07-26 | 2023-08-07 | C.60.02.02.02.12 SS | 102d | 0d | HH [212.76 h] |
| C.60.02.02.02.11 |  | Encofrado recto |  | 4d | 2023-08-04 | 2023-08-07 | C.60.02.02.02.12, C.60.02.02.02.15 FF | 102d | 0d | HH [1147.52 h]; HM [419.49 h] |
| C.60.02.02.02.14 |  | Concreto canal |  | 2d | 2023-08-08 | 2023-08-09 | C.60.02.02.02.11 | 102d | 0d | HH [164.16 h]; HM [17.8 h] |
| C.60.02.02.02.17 |  | Desencofrado |  | 4d | 2023-08-10 | 2023-08-13 | C.60.02.02.02.14 | 102d | 0d | HH [1147.52 h]; HM [419.49 h] |
| C.60.02.02.02.16 |  | Mamposteria de piedra |  | 1d | 2023-08-14 | 2023-08-14 | C.60.02.02.02.17 | 103d |  | HH [27.02 h]; HM [0.46 h] |
|  | 03 | **REPOSICION SIFON INOPERATIVO** |  |  | 2023-07-05 | 2023-08-03 |  |  |  |  |
| C.60.02.03.11 |  | Excavación estructural para obras de arte |  | 14d | 2023-07-05 | 2023-07-18 | C.80.02.16, C.70.10.01.11 SS, C.70.10.03.11 SS | 115d | 0d | HH [321.76 h]; HM [311.39 h] |
| C.60.02.03.12 |  | Colocación de cama de arena |  | 1d | 2023-07-19 | 2023-07-19 | C.60.02.03.11 | 115d | 0d | HH [16.07 h]; HM [6.75 h] |
| C.60.02.03.15 |  | Tuberias HDPE |  | 2d | 2023-07-20 | 2023-07-21 | C.60.02.03.12 | 115d | 0d | HH [37.38 h]; HM [9.12 h] |
| C.60.02.03.21 |  | Codos HDPE |  | 2d | 2023-07-22 | 2023-07-23 | C.60.02.03.15 | 115d | 0d | HH [21 h] |
| C.60.02.03.14 |  | Relleno comun |  | 5d | 2023-07-24 | 2023-07-28 | C.60.02.03.21 | 115d | 0d | HH [86.53 h]; HM [50.82 h] |
| C.60.02.03.16 |  | Concreto - Solado |  | 1d | 2023-07-29 | 2023-07-29 | C.60.02.03.14 | 115d | 0d | HH [1.85 h]; HM [0.23 h] |
| C.60.02.03.20 |  | Acero de refuerzo |  | 1d | 2023-07-30 | 2023-07-30 | C.60.02.03.16 | 115d | 0d | HH [11.16 h]; HM [7.2 h] |
| C.60.02.03.18 |  | Encofrado |  | 1d | 2023-07-31 | 2023-07-31 | C.60.02.03.20 | 115d | 0d | HH [16.78 h]; HM [6.45 h] |
| C.60.02.03.17 |  | Concreto |  | 1d | 2023-08-01 | 2023-08-01 | C.60.02.03.18 | 115d | 0d | HH [9.45 h]; HM [1.02 h] |
| C.60.02.03.19 |  | Desencofrado |  | 1d | 2023-08-02 | 2023-08-02 | C.60.02.03.17 | 115d | 0d | HH [16.78 h]; HM [6.45 h] |
| C.60.02.03.13 |  | Rellno estructural para obras de arte con material propio |  | 0d | 2023-08-03 | 2023-08-03 | C.60.02.03.19 | 115d |  |  |
|  | 21 | **REGISTROS Y CAMARAS** |  |  | 2023-07-06 | 2023-09-28 |  |  |  |  |
|  | 01 | **CAPTACION A3-CP-23-95** |  |  | 2023-07-06 | 2023-09-14 |  |  |  |  |
|  | 01 | **MOVIMIENTO DE TIERRAS** |  |  | 2023-07-24 | 2023-09-12 |  |  |  |  |
| C.21.01.01.11 |  | Excavación estructural para obras de arte |  | 8d | 2023-07-24 | 2023-07-31 | C.21.01.04.11 SS | 90d | 0d | HH [179.07 h]; HM [173.3 h] |
| C.21.01.01.12 |  | Relleno estructural para obras de arte con material propio |  | 3d | 2023-09-10 | 2023-09-12 | C.21.01.02.13, C.21.01.04.13 SS, C.21.01.05.12 SS, C.21.01.06.12 SS | 74d |  | HH [62.73 h]; HM [60.7 h] |

| ID | WBS | Activity | Duration | Start | Finish | Predecessors | Total float | Free float | Resources |
| --- | --- | --- | --- | --- | --- | --- | --- | --- | --- |
|  | 02 | **OBRAS DE CONCRETO** |  | 2023-08-01 | 2023-08-27 |  |  |  |  |
| C.21.01.02.11 |  | Concreto - solado | 1d | 2023-08-01 | 2023-08-01 | C.21.01.01.11 | 90d | 0d | HH [36.07 h]; HM [4.45 h] |
| C.21.01.02.16 |  | Acero de refuerzo | 9d | 2023-08-02 | 2023-08-10 | C.21.01.02.11 | 90d | 0d | HH [854.9 h]; HM [551.55 h] |
| C.21.01.02.14 |  | Encofrado | 5d | 2023-08-11 | 2023-08-15 | C.21.01.02.16 | 90d | 0d | HH [163.28 h]; HM [62.79 h] |
| C.21.01.02.12 |  | Concreto - muro | 6d | 2023-08-16 | 2023-08-21 | C.21.01.02.14 | 90d | 0d | HH [376.77 h]; HM [40.86 h] |
| C.21.01.02.13 |  | Concreto Ciclopeo | 1d | 2023-08-22 | 2023-08-22 | C.21.01.02.12 | 90d | 0d | HH [52.5 h]; HM [4.2 h] |
| C.21.01.02.15 |  | Desencofrado | 5d | 2023-08-23 | 2023-08-27 | C.21.01.02.13 | 90d |  | HH [163.28 h]; HM [62.79 h] |
|  | 03 | **ESTRUCTURAS METALICAS** |  | 2023-08-02 | 2023-08-10 |  |  |  |  |
| C.21.01.03.11 |  | Compuerta metalica | 0d | 2023-08-02 | 2023-08-02 | C.21.01.06.19 | 107d | 0d |  |
| C.21.01.03.12 |  | Rejilla | 1d | 2023-08-02 | 2023-08-02 | C.21.01.03.11 | 107d | 0d | HH [21 h]; HM [10 h] |
| C.21.01.03.13 |  | Baranda de fierro galvanizado | 1d | 2023-08-03 | 2023-08-03 | C.21.01.03.12 | 107d | 0d | HH [2.49 h]; HM [0.6 h] |
| C.21.01.03.14 |  | Escalera tipo gato | 1d | 2023-08-04 | 2023-08-04 | C.21.01.03.13 | 107d | 0d | HH [20.75 h]; HM [5 h] |
| C.21.01.03.15 |  | Tapa metálica | 6d | 2023-08-05 | 2023-08-10 | C.21.01.03.14 | 107d |  | HH [181 h]; HM [28 h] |
|  | 04 | **TUBERIA** |  | 2023-07-06 | 2023-08-09 |  |  |  |  |
| C.21.01.04.12 |  | Excavación de zanja | 8d | 2023-07-06 | 2023-07-13 | C.70.10.05.2.11, C.70.10.02.2.11 | 74d | 0d | HH [333.01 h]; HM [163.72 h] |
| C.21.01.04.14 |  | Cama de arena | 2d | 2023-07-14 | 2023-07-15 | C.21.01.04.12 | 74d | 0d | HH [30.28 h]; HM [12.73 h] |
| C.21.01.04.23 |  | Instalación tubería | 2d | 2023-07-16 | 2023-07-17 | C.21.01.04.14 | 74d | 0d | HH [44.88 h]; HM [10.95 h] |
| C.21.01.04.15 |  | Relleno común para zanjas | 6d | 2023-07-18 | 2023-07-23 | C.21.01.04.23 | 74d | 0d | HH [238.05 h]; HM [139.81 h] |
| C.21.01.04.11 |  | Excavación estructural para obras de arte | 3d | 2023-07-24 | 2023-07-26 | C.21.01.04.15 | 74d | 0d | HH [53.34 h]; HM [41.03 h] |
| C.21.01.04.16 |  | Concreto solado - Buzones | 1d | 2023-07-27 | 2023-07-27 | C.21.01.04.11 | 108d | 0d | HH [6.65 h]; HM [0.82 h] |
| C.21.01.04.20 |  | Acero de refuerzo | 3d | 2023-07-28 | 2023-07-30 | C.21.01.04.16 | 108d | 0d | HH [70.52 h]; HM [45.5 h] |
| C.21.01.04.18 |  | Encofrado recto | 1d | 2023-07-31 | 2023-07-31 | C.21.01.04.20 | 110d | 2d | HH [21.84 h]; HM [8.4 h] |
| C.21.01.04.19 |  | Encofrado curvo | 3d | 2023-07-31 | 2023-08-02 | C.21.01.04.20 | 108d | 0d | HH [52.12 h]; HM [32.57 h] |
| C.21.01.04.17 |  | Concreto - Buzones | 1d | 2023-08-03 | 2023-08-03 | C.21.01.04.18, C.21.01.04.19 | 108d | 0d | HH [35.17 h]; HM [3.81 h] |
| C.21.01.04.21 |  | Desencofrado recto | 1d | 2023-08-04 | 2023-08-04 | C.21.01.04.17 | 110d | 2d | HH [21.84 h]; HM [8.4 h] |
| C.21.01.04.22 |  | Desencodrado curvo | 3d | 2023-08-04 | 2023-08-06 | C.21.01.04.17 | 108d | 0d | HH [52.12 h]; HM [32.57 h] |
| C.21.01.04.13 |  | Relleno estructural para obras de arte con material propio | 3d | 2023-08-07 | 2023-08-09 | C.21.01.04.21, C.21.01.04.22 | 108d | 34d | HH [51.74 h]; HM [22.95 h] |

| ID | WBS | Activity | Type | Duration | Start | Finish | Predecessors | Total float | Free float | Resources |
| --- | --- | --- | --- | --- | --- | --- | --- | --- | --- | --- |
|  | 05 | **CANALES** |  |  | 2023-07-24 | 2023-09-14 |  |  |  |  |
| C.21.01.05.11 |  | Excavación estructural para obras de arte |  | 4d | 2023-07-24 | 2023-07-27 | C.21.01.04.11 SS | 74d | 0d | HH [186.73 h]; HM [180.71 h] |
| C.21.01.05.13 |  | Colocación solado |  | 2d | 2023-07-28 | 2023-07-29 | C.21.01.05.11 | 74d | 0d | HH [107.94 h]; HM [13.32 h] |
| C.21.01.05.16 |  | Acero de refuerzo |  | 10d | 2023-07-30 | 2023-08-08 | C.21.01.05.13 | 74d | 0d | HH [1769.22 h]; HM [1141.43 h] |
| C.21.01.05.18 |  | Junta Water Stop | level of effort | 22d | 2023-07-30 | 2023-08-20 | C.21.01.05.16 SS | 74d | 0d | HH [33.43 h] |
| C.21.01.05.15 |  | Encofrado |  | 12d | 2023-08-09 | 2023-08-20 | C.21.01.05.16, C.21.01.05.18 FF | 74d | 0d | HH [3523.21 h]; HM [1354.97 h] |
| C.21.01.05.14 |  | Colocación concreto |  | 8d | 2023-08-21 | 2023-08-28 | C.21.01.05.15 | 74d | 0d | HH [539.08 h]; HM [58.46 h] |
| C.21.01.05.17 |  | Desencofrado |  | 12d | 2023-08-29 | 2023-09-09 | C.21.01.05.14 | 74d | 0d | HH [3523.21 h]; HM [1354.97 h] |
| C.21.01.05.12 |  | Relleno estructural para canales |  | 5d | 2023-09-10 | 2023-09-14 | C.21.01.05.17 | 74d | 0d | HH [413.99 h]; HM [183.61 h] |
|  | 06 | **OBRAS DE DESCARGA** |  |  | 2023-07-24 | 2023-08-06 |  |  |  |  |
| C.21.01.06.11 |  | Excavación estructural para obras de arte |  | 1d | 2023-07-24 | 2023-07-24 | C.21.01.04.11 SS | 107d | 0d | HH [7.88 h]; HM [7.63 h] |
| C.21.01.06.13 |  | Concreto - solado |  | 1d | 2023-07-25 | 2023-07-25 | C.21.01.06.11 | 107d | 0d | HH [2.37 h]; HM [0.29 h] |
| C.21.01.06.17 |  | Acero de refuerzo |  | 1d | 2023-07-26 | 2023-07-26 | C.21.01.06.13 | 107d | 0d | HH [9.62 h]; HM [6.21 h] |
| C.21.01.06.18 |  | Junta Water Stop | level of effort | 3d | 2023-07-26 | 2023-07-28 | C.21.01.06.17 SS | 107d | 0d | HH [33.26 h] |
| C.21.01.06.15 |  | Encofrado recto |  | 2d | 2023-07-27 | 2023-07-28 | C.21.01.06.17, C.21.01.06.18 FF | 107d | 0d | HH [41.36 h]; HM [15.91 h] |
| C.21.01.06.14 |  | Concreto canal |  | 1d | 2023-07-29 | 2023-07-29 | C.21.01.06.15 | 107d | 0d | HH [10.08 h]; HM [1.09 h] |
| C.21.01.06.16 |  | Desencofrado |  | 2d | 2023-07-30 | 2023-07-31 | C.21.01.06.14 | 114d | 0d | HH [41.36 h]; HM [15.91 h] |
| C.21.01.06.19 |  | Compuerta metalica |  | 3d | 2023-07-30 | 2023-08-01 | C.21.01.06.14 | 107d | 0d | HH [92.5 h]; HM [15 h] |
| C.21.01.06.12 |  | Relleno estructural para obras de arte con material propio |  | 6d | 2023-08-01 | 2023-08-06 | C.21.01.06.16 | 114d | 40d | HH [162.56 h]; HM [72.1 h] |
|  | 02 | **CAPTACION A3-CP-21-05** |  |  | 2023-07-23 | 2023-09-03 |  |  |  |  |
|  | 01 | **MOVIMIENTO DE TIERRAS** |  |  | 2023-07-28 | 2023-08-19 |  |  |  |  |
| C.21.02.01.11 |  | Excavación estructural para obras de arte |  | 5d | 2023-07-28 | 2023-08-01 | C.21.02.04.15 | 83d | 0d | HH [110.68 h]; HM [107.12 h] |
| C.21.02.01.12 |  | Relleno estructural para obras de arte con material propio |  | 1d | 2023-08-19 | 2023-08-19 | C.21.02.05.12 SS | 98d |  | HH [25.19 h]; HM [11.17 h] |
|  | 02 | **OBRAS DE CONCRETO** |  |  | 2023-08-02 | 2023-08-25 |  |  |  |  |
| C.21.02.02.11 |  | Concreto - solado |  | 1d | 2023-08-02 | 2023-08-02 | C.21.02.01.11 | 83d | 0d | HH [31.27 h]; HM [3.86 h] |
| C.21.02.02.16 |  | Acero de refuerzo |  | 7d | 2023-08-03 | 2023-08-09 | C.21.02.02.11 | 83d | 0d | HH [892.59 h]; HM [575.87 h] |
| C.21.02.02.14 |  | Encofrado |  | 5d | 2023-08-10 | 2023-08-14 | C.21.02.02.16 | 83d | 0d | HH [498.83 h]; HM [191.84 h] |
| C.21.02.02.12 |  | Concreto - muro |  | 6d | 2023-08-15 | 2023-08-20 | C.21.02.02.14 | 83d | 0d | HH [359.02 h]; HM [38.93 h] |
| C.21.02.02.13 |  | Concreto Ciclopeo |  | 1d | 2023-08-15 | 2023-08-15 | C.21.02.02.14 | 88d | 5d | HH [36.38 h]; HM [2.91 h] |
| C.21.02.02.15 |  | Desencofrado |  | 5d | 2023-08-21 | 2023-08-25 | C.21.02.02.12, C.21.02.02.13 | 83d | 0d | HH [498.83 h]; HM [191.84 h] |

| ID | WBS | Activity | Type | Duration | Start | Finish | Predecessors | Total float | Free float | Resources |
| --- | --- | --- | --- | --- | --- | --- | --- | --- | --- | --- |
|  | 03 | **ESTRUCTURAS METALICAS** |  |  | 2023-08-26 | 2023-09-03 |  |  |  |  |
| C.21.02.03.11 |  | Compuerta metalica |  | 4d | 2023-08-26 | 2023-08-29 | C.21.02.02.15 | 83d | 0d | HH [103 h]; HM [50 h] |
| C.21.02.03.12 |  | Rejilla |  | 1d | 2023-08-30 | 2023-08-30 | C.21.02.03.11 | 83d | 0d | HH [21 h]; HM [10 h] |
| C.21.02.03.13 |  | Baranda de fierro galvanizado |  | 1d | 2023-08-31 | 2023-08-31 | C.21.02.03.12 | 83d | 0d | HH [2.49 h]; HM [0.6 h] |
| C.21.02.03.14 |  | Escalera tipo gato |  | 1d | 2023-09-01 | 2023-09-01 | C.21.02.03.13 | 83d | 0d | HH [20.75 h]; HM [5 h] |
| C.21.02.03.15 |  | Tapa metálica |  | 2d | 2023-09-02 | 2023-09-03 | C.21.02.03.14 | 83d |  | HH [45.25 h]; HM [7 h] |
|  | 04 | **TUBERÍA** |  |  | 2023-07-23 | 2023-08-06 |  |  |  |  |
| C.21.02.04.12 |  | Excavación de zanja |  | 1d | 2023-07-23 | 2023-07-23 | C.70.10.03.11, C.70.10.01.11 | 83d | 0d | HH [16.24 h]; HM [7.98 h] |
| C.21.02.04.14 |  | Cama de arena |  | 1d | 2023-07-24 | 2023-07-24 | C.21.02.04.12 | 83d | 0d | HH [1.76 h]; HM [0.74 h] |
| C.21.02.04.23 |  | Instalación tubería |  | 1d | 2023-07-25 | 2023-07-25 | C.21.02.04.14 | 83d | 0d | HH [3.23 h]; HM [0.79 h] |
| C.21.02.04.15 |  | Relleno común para zanjas |  | 2d | 2023-07-26 | 2023-07-27 | C.21.02.04.23 | 83d | 0d | HH [16.58 h]; HM [10.46 h] |
| C.21.02.04.11 |  | Excavación estructural para obras de arte |  | 1d | 2023-07-28 | 2023-07-28 | C.21.02.04.15 | 111d | 0d | HH [13.73 h]; HM [10.56 h] |
| C.21.02.04.16 |  | Concreto solado - Buzones |  | 1d | 2023-07-29 | 2023-07-29 | C.21.02.04.11 | 111d | 0d | HH [2.75 h]; HM [0.34 h] |
| C.21.02.04.20 |  | Acero de refuerzo |  | 2d | 2023-07-30 | 2023-07-31 | C.21.02.04.16 | 111d | 0d | HH [27.02 h]; HM [17.44 h] |
| C.21.02.04.18 |  | Encofrado recto |  | 1d | 2023-08-01 | 2023-08-01 | C.21.02.04.20 | 112d | 1d | HH [7.77 h]; HM [2.99 h] |
| C.21.02.04.19 |  | Encofrado curvo |  | 2d | 2023-08-01 | 2023-08-02 | C.21.02.04.20 | 111d | 0d | HH [36.25 h]; HM [22.65 h] |
| C.21.02.04.17 |  | Concreto - Buzones |  | 1d | 2023-08-03 | 2023-08-03 | C.21.02.04.18, C.21.02.04.19 | 111d | 0d | HH [22.03 h]; HM [2.39 h] |
| C.21.02.04.21 |  | Desencofrado recto |  | 1d | 2023-08-04 | 2023-08-04 | C.21.02.04.17 | 112d | 1d | HH [7.77 h]; HM [2.99 h] |
| C.21.02.04.22 |  | Desencodrado curvo |  | 2d | 2023-08-04 | 2023-08-05 | C.21.02.04.17 | 111d | 0d | HH [36.25 h]; HM [22.65 h] |
| C.21.02.04.13 |  | Relleno estructural para obras de arte con material propio |  | 1d | 2023-08-06 | 2023-08-06 | C.21.02.04.21, C.21.02.04.22 | 111d |  | HH [10.57 h]; HM [4.69 h] |
|  | 05 | **CANALES** |  |  | 2023-07-28 | 2023-08-25 |  |  |  |  |
| C.21.02.05.11 |  | Excavación estructural para obras de arte |  | 7d | 2023-07-28 | 2023-08-03 | C.21.02.04.15 | 98d | 0d | HH [152.82 h]; HM [147.9 h] |
| C.21.02.05.13 |  | Colocación solado |  | 1d | 2023-08-04 | 2023-08-04 | C.21.02.05.11 | 98d | 0d | HH [24.8 h]; HM [3.06 h] |
| C.21.02.05.16 |  | Acero de refuerzo |  | 3d | 2023-08-05 | 2023-08-07 | C.21.02.05.13 | 98d | 0d | HH [547.96 h]; HM [353.52 h] |
| C.21.02.05.18 |  | Junta Water Stop | level of effort | 7d | 2023-08-05 | 2023-08-11 | C.21.02.05.16 SS | 98d | 0d | HH [8.3 h] |
| C.21.02.05.15 |  | Encofrado |  | 4d | 2023-08-08 | 2023-08-11 | C.21.02.05.16, C.21.02.05.18 FF | 98d | 0d | HH [986.63 h]; HM [379.44 h] |
| C.21.02.05.14 |  | Colocación concreto |  | 3d | 2023-08-12 | 2023-08-14 | C.21.02.05.15 | 98d | 0d | HH [143.1 h]; HM [15.52 h] |
| C.21.02.05.17 |  | Desencofrado |  | 4d | 2023-08-15 | 2023-08-18 | C.21.02.05.14 | 98d | 0d | HH [986.63 h]; HM [379.44 h] |
| C.21.02.05.12 |  | Relleno estructural para canales |  | 7d | 2023-08-19 | 2023-08-25 | C.21.02.05.17 | 98d | 0d | HH [197.05 h]; HM [87.4 h] |

| ID | WBS | Activity | Type | Duration | Start | Finish | Predecessors | Total float | Free float | Resources |
| --- | --- | --- | --- | --- | --- | --- | --- | --- | --- | --- |
|  | 03 | **RETORNO A3-OA-RE-D-21-55** |  |  | 2023-07-23 | 2023-09-28 |  |  |  |  |
|  | 01 | **MOVIMIENTO DE TIERRAS** |  |  | 2023-07-23 | 2023-09-25 |  |  |  |  |
| C.21.03.01.11 |  | Excavación estructural para obras de arte |  | 1d | 2023-07-23 | 2023-07-23 | C.70.10.01.11, C.70.10.03.11 | 58d | 0d | HH [20.99 h]; HM [20.32 h] |
| C.21.03.01.12 |  | Relleno estructural para obras de arte con material propio |  | 0d | 2023-09-25 | 2023-09-25 | C.21.03.02.17 | 62d |  |  |
|  | 02 | **OBRAS DE CONCRETO** |  |  | 2023-07-24 | 2023-09-24 |  |  |  |  |
| C.21.03.02.11 |  | Concreto - solado |  | 1d | 2023-07-24 | 2023-07-24 | C.21.03.01.11 | 58d | 0d | HH [16.14 h]; HM [1.99 h] |
| C.21.03.02.15 |  | Acero de refuerzo |  | 46d | 2023-07-25 | 2023-09-08 | C.21.03.02.11 | 58d | 0d | HH [1073.28 h]; HM [692.44 h] |
| C.21.03.02.16 |  | Junta Water Stop | level of effort | 52d | 2023-07-25 | 2023-09-14 | C.21.03.02.15 SS | 58d | 0d | HH [33.33 h] |
| C.21.03.02.14 |  | Encofrado |  | 6d | 2023-09-09 | 2023-09-14 | C.21.03.02.15, C.21.03.02.16 FF | 58d | 0d | HH [199.58 h]; HM [76.76 h] |
| C.21.03.02.12 |  | Concreto |  | 2d | 2023-09-15 | 2023-09-16 | C.21.03.02.14 | 60d | 2d | HH [141.23 h]; HM [15.32 h] |
| C.21.03.02.13 |  | Concreto Ciclopeo |  | 4d | 2023-09-15 | 2023-09-18 | C.21.03.02.14 | 58d | 0d | HH [349.62 h]; HM [27.97 h] |
| C.21.03.02.17 |  | Desencofrado |  | 6d | 2023-09-19 | 2023-09-24 | C.21.03.02.12, C.21.03.02.13 | 58d | 0d | HH [199.58 h]; HM [76.76 h] |
|  | 03 | **ESTRUCTURAS METALICAS** |  |  | 2023-09-25 | 2023-09-28 |  |  |  |  |
| C.21.03.03.11 |  | Compuerta metalica plana |  | 4d | 2023-09-25 | 2023-09-28 | C.21.03.02.17 | 58d |  | HH [154.5 h]; HM [75 h] |
| C.21.03.03.12 |  | Baranda de fierro galvanizado |  | 1d | 2023-09-25 | 2023-09-25 | C.21.03.02.17 | 61d |  | HH [8.3 h]; HM [2 h] |
|  | T | **CIERRE** |  |  | 2023-11-26 | 2023-12-02 |  |  |  |  |
|  | 20 | **DESMOVILIZACIÓN** |  |  | 2023-11-26 | 2023-12-02 |  |  |  |  |
| T.20.11 |  | Desmovilización equipos |  | 4d | 2023-11-26 | 2023-11-29 | C.90.02.04.13, C.70.02.01.03.16, C.70.02.01.03.13, C.70.02.01.02.01.11, C.70.02.01.02.02.11, C.70.02.01.01.11, C.70.02.01.01.14, C.70.02.01.01.13, C.70.02.01.01.12, C.70.10.01.15, C.70.10.02.1.15, C.70.10.02.2.15, C.70.10.02.3.14, C.70.10.03.15, C.70.10.04.15, C.70.10.05.1.15, C.70.10.05.2.15, C.70.11.01.13, C.70.11.02.13, C.60.02.01.02.16, C.60.02.02.02.16, C.60.02.03.13, C.21.01.03.15, C.21.02.03.15, C.21.03.03.12, C.21.03.03.11, C.21.03.01.12, C.60.02.01.01.12, C.60.02.02.01.12, C.21.01.01.12, C.21.01.02.15, C.21.02.01.12, C.21.02.04.13 | 0d |  |  |
| T.20.12 |  | Desmovilización equipos - Paisajismo |  | 3d | 2023-11-30 | 2023-12-02 | T.20.11, C.70.03.03.11, C.70.05.01.17 | 0d |  |  |

## Activity codes

| Code | Value | Meaning |
| --- | --- | --- |
| SECTOR | S1 | SECTOR 1 |
| SECTOR | S2 | SECTOR 2 |
| SECTOR | S3 | SECTOR 3 |
| SECTOR | S4 | SECTOR 4 |
| SECTOR | S5 | SECTOR 5 |
